# NEW_EXONE_1

Schedule from MS Project, 2017-01-03 to 2017-04-04, costs in €.

## Calendars

- Standard: Mon-Fri 08:00-12:00, 13:00-17:00; Sat-Sun off.

## Resources

| Resource | Rate |
| --- | --- |
| EDTR3 | 37.5 |
| EDTR4 | 37.5 |
| PRFRDR1 | 31.25 |
| PRFRDR2 | 31.25 |
| OPM | 56.25 |
| EDTR1 | 37.5 |
| EDTR2 | 37.5 |
| TSTSP | 43.75 |
| HW | 3000 |
| CTR_COST |  |
| MMLIC | 2000 |
| CTR |  |
| DATENG | 50 |
| TRAVEL |  |

## Schedule

| ID | WBS | Task | Type | Duration | Start | Finish | Predecessors | Total slack | Free slack | Constraint | Resources | Work | Cost |
| --- | --- | --- | --- | --- | --- | --- | --- | --- | --- | --- | --- | --- | --- |
| 1 | 1 | **PROJECT EXONE** |  | 66d | 2017-01-03 | 2017-04-04 |  | 0d |  | start no earlier than 2011-01-03 |  | 1600h | 145,734 |
| 2 | 1.1 | **REQUIREMENTS** |  | 4d | 2017-01-03 | 2017-01-06 |  | 0d |  |  |  | 88h | 4,000 |
| 3 | 1.1.1 | Review and complete requirements & plan with contractor | manual | 3d | 2017-01-03 | 2017-01-05 |  |  |  |  | CTR; OPM; DATENG; TRAVEL [0.1%] | 72h | 3,550 |
| 4 | 1.1.2 | Final discussion and agreement with contractor on req'ts & plan |  | 1d | 2017-01-06 | 2017-01-06 | 3 | 0d |  |  | CTR; OPM | 16h | 450 |
| 5 | 1.2 | **SOFTWARE DESIGN** |  | 11d | 2017-01-09 | 2017-01-23 |  | 0d |  |  |  | 96h | 850 |
| 6 | 1.2.1 | Write and check design specifications |  | 9d | 2017-01-09 | 2017-01-19 | 4 | 0d |  |  | CTR | 72h |  |
| 7 | 1.2.2 | Meet with contractor to discuss & agree on design |  | 2d | 2017-01-20 | 2017-01-23 | 6 | 0d |  |  | OPM [50%]; CTR; TRAVEL [0.1%] | 24h | 850 |
| 8 | 1.3 | **SOFTWARE IMPLEMENTATION** |  | 46d | 2017-01-24 | 2017-03-28 |  | 0d |  |  |  | 280h |  |
| 9 | 1.3.1 | Coding, internal testing & bug fixing - Alpha version |  | 12d | 2017-01-24 | 2017-02-08 | 7 | 0d |  |  | CTR | 96h |  |
| 10 | 1.3.2 | Delivery of Alpha version by contractor |  | 1d | 2017-02-10 | 2017-02-10 | 21 | 0d |  |  | CTR | 8h |  |
| 11 | 1.3.3 | Debugging following Alpha testing |  | 2d | 2017-02-15 | 2017-02-16 | 28 | 0d |  |  | CTR | 16h |  |
| 12 | 1.3.4 | Coding, internal testing & bug fixing - Beta version |  | 12d | 2017-02-17 | 2017-03-06 | 11 | 0d |  |  | CTR | 96h |  |
| 13 | 1.3.5 | Delivery of Beta version by contractor |  | 1d | 2017-03-09 | 2017-03-09 | 25, 12 | 0d |  |  | CTR | 8h |  |
| 14 | 1.3.6 | Debugging following Beta testing |  | 4d | 2017-03-16 | 2017-03-21 | 29 | 0d |  |  | CTR | 32h |  |
| 15 | 1.3.7 | Delivery of Final version by contractor |  | 1d | 2017-03-22 | 2017-03-22 | 14 | 0d |  |  | CTR | 8h |  |
| 16 | 1.3.8 | Debugging following Final testing & delivery for acceptance |  | 2d | 2017-03-27 | 2017-03-28 | 30 | 0d |  |  | CTR | 16h |  |
| 17 | 1.4 | **CONTENT CREATION & INTEGRATION** |  | 32d | 2017-01-24 | 2017-03-08 |  | 0d |  |  |  | 552h | 19,800 |
| 18 | 1.4.1 | Creation of content subset |  | 6d | 2017-01-24 | 2017-01-31 | 7 | 2d | 0d |  | EDTR1; EDTR2; EDTR3; EDTR4 | 192h | 7,200 |
| 19 | 1.4.2 | Proofreading of content subset |  | 3d | 2017-01-30 | 2017-02-01 | 18SS+4d | 2d | 0d |  | PRFRDR1; PRFRDR2 | 48h | 1,500 |
| 20 | 1.4.3 | Preparation of content subset & delivery to contractor |  | 3d | 2017-02-02 | 2017-02-06 | 9FF-2d, 19 | 2d |  |  | DATENG | 24h | 1,200 |
| 21 | 1.4.4 | Integration of content subset |  | 1d | 2017-02-09 | 2017-02-09 | 20, 9 | 0d |  |  | CTR | 8h |  |
| 22 | 1.4.5 | Creation of complementary content |  | 6d | 2017-02-15 | 2017-02-22 | 28, 27 | 4d | 0d |  | EDTR1; EDTR2; EDTR3; EDTR4 | 192h | 7,200 |
| 23 | 1.4.6 | Proofreading of complementary content |  | 3d | 2017-02-21 | 2017-02-23 | 22SS+4d | 4d | 2d |  | PRFRDR1; PRFRDR2 | 48h | 1,500 |
| 24 | 1.4.7 | Preparation of complementary content & delivery to contractor |  | 3d | 2017-02-28 | 2017-03-02 | 12FF-2d, 23 | 2d |  |  | DATENG | 24h | 1,200 |
| 25 | 1.4.8 | Integration of complementary content |  | 2d | 2017-03-07 | 2017-03-08 | 24, 12 | 0d |  |  | CTR | 16h |  |

| ID | WBS | Task | Type | Duration | Start | Finish | Predecessors | Total slack | Constraint | Resources | Work | Cost |
| --- | --- | --- | --- | --- | --- | --- | --- | --- | --- | --- | --- | --- |
| 26 | 1.5 | **TESTING & ACCEPTANCE** |  | 41d | 2017-02-01 | 2017-03-29 |  | 0d |  |  | 268h | 10,375 |
| 27 | 1.5.1 | Prepare test plan and test cases |  | 4d | 2017-02-01 | 2017-02-06 | 18, 22 | 4d |  | EDTR1; EDTR2 | 64h | 2,400 |
| 28 | 1.5.2 | Alpha testing |  | 2d | 2017-02-13 | 2017-02-14 | 10, 27 | 0d |  | EDTR3; EDTR4 | 32h | 1,200 |
| 29 | 1.5.3 | Beta testing |  | 4d | 2017-03-10 | 2017-03-15 | 13 | 0d |  | EDTR3; EDTR4; TSTSP | 96h | 3,800 |
| 30 | 1.5.4 | Final testing |  | 2d | 2017-03-23 | 2017-03-24 | 15 | 0d |  | EDTR3; EDTR4; TSTSP [50%] | 40h | 1,550 |
| 31 | 1.5.5 | Acceptance |  | 1d | 2017-03-29 | 2017-03-29 | 16 | 0d |  | OPM [50%]; EDTR1; EDTR2; EDTR3; EDTR4 | 36h | 1,425 |
| 32 | 1.6 | DEPLOYMENT |  | 2d | 2017-03-30 | 2017-03-31 | 31 | 0d |  | CTR | 16h |  |
| 33 | 1.7 | PROJECT MANAGEMENT (After Req'ts WP & before Closure) |  | 60d | 2017-01-09 | 2017-03-31 | 2, 32FF | 0d | start no earlier than 2012-01-06 | OPM [50%] | 240h | 13,500 |
| 34 | 1.8 | CONTRACTOR'S PROJECT CLOSURE |  | 1d | 2017-04-03 | 2017-04-03 | 33 | 0d |  | OPM [50%]; CTR; TRAVEL [0.1%] | 12h | 475 |
| 35 | 1.9 | OVERALL PROJECT CLOSURE |  | 1d | 2017-04-04 | 2017-04-04 | 34 | 0d |  | DATENG; EDTR1; EDTR3; OPM; EDTR2; EDTR4 | 48h | 2,050 |
| 36 | 1.10 | COST OF WORK DONE BY CONTRACTOR | manual | 1d | 2017-01-03 | 2017-01-03 |  |  |  | CTR_COST [0.1%] |  | 89,684 |
| 37 | 1.11 | OTHER NON-LABOUR COSTS | manual | 1d | 2017-01-03 | 2017-01-03 |  |  | start no earlier than 2012-01-02 | HW; MMLIC |  | 5,000 |
