# NEW_EXONE_1

Schedule from MS Project, 2017-01-03 to 2017-04-03, costs in €.

## Calendars

- Standard: Mon-Fri 08:00-12:00, 13:00-17:00; Sat-Sun off.

## Resources

| Resource | Rate |
| --- | --- |
| DVPR1 | 50 |
| DVPR2 | 43.75 |
| TSTR1 | 37.5 |
| TSTR2 | 37.5 |
| PM | 62.5 |
| STC | 56.25 |
| JTC | 43.75 |
| CLT |  |
| TRAVEL |  |

## Schedule

| ID | WBS | Task | Type | Duration | Start | Finish | Predecessors | Total slack | Constraint | Resources | Work | Cost |
| --- | --- | --- | --- | --- | --- | --- | --- | --- | --- | --- | --- | --- |
| 1 | 1 | **PROJECT EXONE** |  | 65d | 2017-01-03 | 2017-04-03 |  | 0d | start no earlier than 2011-01-03 |  | 1416h | 65,225 |
| 2 | 1.1 | **REQUIREMENTS** |  | 4d | 2017-01-03 | 2017-01-06 |  | 0d |  |  | 112h | 4,550 |
| 3 | 1.1.1 | Review and complete requirements & plan with client | manual | 3d | 2017-01-03 | 2017-01-05 |  |  |  | STC; DVPR1; CLT; PM | 96h | 4,050 |
| 4 | 1.1.2 | Final discussion and agreement with client on req'ts & plan |  | 1d | 2017-01-06 | 2017-01-06 | 3 | 0d |  | CLT; PM | 16h | 500 |
| 5 | 1.2 | **DESIGN** |  | 11d | 2017-01-09 | 2017-01-23 |  | 0d |  |  | 208h | 10,350 |
| 6 | 1.2.1 | Write design specifications |  | 7d | 2017-01-09 | 2017-01-17 | 4 | 0d |  | DVPR1; STC | 112h | 5,950 |
| 7 | 1.2.2 | Check design with respect to requirements |  | 2d | 2017-01-18 | 2017-01-19 | 6 | 0d |  | DVPR1; STC; PM [50%] | 40h | 2,200 |
| 8 | 1.2.3 | Meet with client to discuss & agree on design |  | 2d | 2017-01-20 | 2017-01-23 | 7 | 0d |  | STC; PM [50%]; DVPR1; CLT | 56h | 2,200 |
| 9 | 1.3 | **IMPLEMENTATION** |  | 46d | 2017-01-24 | 2017-03-28 |  | 0d |  |  | 488h | 22,800 |
| 10 | 1.3.1 | Coding - Alpha version |  | 7d | 2017-01-24 | 2017-02-01 | 8 | 2d |  | DVPR2; DVPR1 | 112h | 5,250 |
| 11 | 1.3.2 | Debugging phase 1 (following internal Alpha testing) |  | 3d | 2017-02-06 | 2017-02-08 | 27, 10 | 0d |  | DVPR2; DVPR1 | 48h | 2,250 |
| 12 | 1.3.3 | Production of Alpha version and delivery to client |  | 1d | 2017-02-10 | 2017-02-10 | 22 | 0d |  | DVPR2 | 8h | 350 |
| 13 | 1.3.4 | Debugging phase 2 (following client Alpha testing) |  | 2d | 2017-02-15 | 2017-02-16 | 28 | 0d |  | DVPR1; DVPR2 | 32h | 1,500 |
| 14 | 1.3.5 | Coding - Beta version |  | 8d | 2017-02-17 | 2017-02-28 | 13 | 0d |  | DVPR2; DVPR1 | 128h | 6,000 |
| 15 | 1.3.6 | Debugging phase 3 (following internal Beta testing) |  | 3d | 2017-03-02 | 2017-03-06 | 29, 14 | 0d |  | DVPR2; DVPR1 | 48h | 2,250 |
| 16 | 1.3.7 | Production of Beta version and delivery to client |  | 1d | 2017-03-09 | 2017-03-09 | 24 | 0d |  | DVPR2 | 8h | 350 |
| 17 | 1.3.8 | Debugging phase 4 (following client Beta testing) |  | 4d | 2017-03-16 | 2017-03-21 | 30 | 0d |  | DVPR1; DVPR2 | 64h | 3,000 |
| 18 | 1.3.9 | Production of Final version and delivery to client |  | 1d | 2017-03-22 | 2017-03-22 | 17 | 0d |  | DVPR2 | 8h | 350 |
| 19 | 1.3.10 | Debugging phase 5 & delivery (following client Final testing) |  | 2d | 2017-03-27 | 2017-03-28 | 31 | 0d |  | DVPR2; DVPR1 | 32h | 1,500 |
| 20 | 1.4 | **INTEGRATION** |  | 23d | 2017-02-06 | 2017-03-08 |  | 0d |  |  | 40h | 1,050 |
| 21 | 1.4.1 | Delivery of content subset by client |  | 1d | 2017-02-06 | 2017-02-06 | 11FF-2d | 2d |  | CLT | 8h |  |
| 22 | 1.4.2 | Integration of content subset |  | 1d | 2017-02-09 | 2017-02-09 | 21, 11 | 0d |  | DVPR2 | 8h | 350 |
| 23 | 1.4.3 | Delivery of complementary content by client |  | 1d | 2017-03-02 | 2017-03-02 | 15FF-2d | 2d |  | CLT | 8h |  |
| 24 | 1.4.4 | Integration of complementary content |  | 2d | 2017-03-07 | 2017-03-08 | 23, 15 | 0d |  | DVPR2 | 16h | 700 |

| ID | WBS | Task | Duration | Start | Finish | Predecessors | Total slack | Constraint | Resources | Work | Cost |
| --- | --- | --- | --- | --- | --- | --- | --- | --- | --- | --- | --- |
| 25 | 1.5 | **TESTING & ACCEPTANCE** | 47d | 2017-01-24 | 2017-03-29 |  | 0d |  |  | 260h | 7,675 |
| 26 | 1.5.1 | Prepare test plan and test cases | 5d | 2017-01-24 | 2017-01-30 | 8 | 0d |  | STC [50%]; JTC | 60h | 2,875 |
| 27 | 1.5.2 | Internal testing - Alpha version | 4d | 2017-01-31 | 2017-02-03 | 10SS+3d, 26 | 0d |  | TSTR1; TSTR2 | 64h | 2,400 |
| 28 | 1.5.3 | Alpha testing by client | 2d | 2017-02-13 | 2017-02-14 | 12 | 0d |  | CLT | 16h |  |
| 29 | 1.5.4 | Internal testing - Beta version | 4d | 2017-02-24 | 2017-03-01 | 14SS+5d | 0d |  | TSTR1; TSTR2 | 64h | 2,400 |
| 30 | 1.5.5 | Beta testing by client | 4d | 2017-03-10 | 2017-03-15 | 16 | 0d |  | CLT | 32h |  |
| 31 | 1.5.6 | Final testing by client | 2d | 2017-03-23 | 2017-03-24 | 18 | 0d |  | CLT | 16h |  |
| 32 | 1.5.7 | Acceptance by client | 1d | 2017-03-29 | 2017-03-29 | 19 | 0d |  | CLT | 8h |  |
| 33 | 1.6 | DEPLOYMENT AT CLIENT'S SITE | 2d | 2017-03-30 | 2017-03-31 | 32 | 0d |  | DVPR2; JTC; TRAVEL [0.1%] | 32h | 2,150 |
| 34 | 1.7 | PROJECT MANAGEMENT (After Req'ts WP & before Closure) | 60d | 2017-01-09 | 2017-03-31 | 2, 33FF | 0d | start no earlier than 2012-01-06 | PM [50%] | 240h | 15,000 |
| 35 | 1.8 | PROJECT CLOSURE | 1d | 2017-04-03 | 2017-04-03 | 34 | 0d |  | DVPR1; PM; STC; TSTR1; CLT [50%] | 36h | 1,650 |
