# NEW_EXONE_1

Schedule from MS Project, 2017-01-03 to 2017-04-03, costs in €, A marks actual dates.

## Calendars

- Standard: Mon-Fri 08:00-12:00, 13:00-17:00; Sat-Sun off.

## Resources

| Resource | Rate |
| --- | --- |
| DVPR1 | 50 |
| DVPR2 | 43.75 |
| TSTR1 | 37.5 |
| TSTR2 | 37.5 |
| PM | 62.5 |
| STC | 56.25 |
| JTC | 43.75 |
| CLT |  |
| TRAVEL |  |

## Schedule

| ID | WBS | Task | Type | Duration | Start | Finish | Predecessors | Complete | Remaining | Baseline start | Baseline finish | Baseline duration | Total slack | Free slack | Constraint | Resources | Work | Actual work | Cost | Baseline cost | Actual cost |
| --- | --- | --- | --- | --- | --- | --- | --- | --- | --- | --- | --- | --- | --- | --- | --- | --- | --- | --- | --- | --- | --- |
| 1 | 1 | **PROJECT EXONE** |  | 64.5d | 2017-01-03 A | 2017-04-03 |  | 57% | 27.54d | 2017-01-03 | 2017-04-03 | 65d | 0d |  | start no earlier than 2011-01-03 |  | 1352h | 840h | 62,475 | 65,225 | 39,725 |
| 2 | 1.1 | **REQUIREMENTS** |  | 3.5d | 2017-01-03 A | 2017-01-06 A |  | 100% |  | 2017-01-03 | 2017-01-06 | 4d |  |  |  |  | 88h | 88h | 3,625 | 4,550 | 3,625 |
| 3 | 1.1.1 | Review and complete requirements & plan with client | manual | 2.5d | 2017-01-03 A | 2017-01-05 A |  | 100% |  | 2017-01-03 | 2017-01-05 | 3d |  |  |  | STC; DVPR1; CLT; PM | 80h | 80h | 3,375 | 4,050 | 3,375 |
| 4 | 1.1.2 | Final discussion and agreement with client on req'ts & plan |  | 0.5d | 2017-01-06 A | 2017-01-06 A | 3 | 100% |  | 2017-01-06 | 2017-01-06 | 1d |  |  |  | CLT; PM | 8h | 8h | 250 | 500 | 250 |
| 5 | 1.2 | **DESIGN** |  | 10d | 2017-01-06 A | 2017-01-20 A |  | 100% |  | 2017-01-09 | 2017-01-23 | 11d |  |  |  |  | 192h | 192h | 9,500 | 10,350 | 9,500 |
| 6 | 1.2.1 | Write design specifications |  | 6d | 2017-01-06 A | 2017-01-16 A | 4 | 100% |  | 2017-01-09 | 2017-01-17 | 7d |  |  |  | DVPR1; STC | 96h | 96h | 5,100 | 5,950 | 5,100 |
| 7 | 1.2.2 | Check design with respect to requirements |  | 2d | 2017-01-16 A | 2017-01-18 A | 6 | 100% |  | 2017-01-18 | 2017-01-19 | 2d |  |  |  | DVPR1; STC; PM [50%] | 40h | 40h | 2,200 | 2,200 | 2,200 |
| 8 | 1.2.3 | Meet with client to discuss & agree on design |  | 2d | 2017-01-18 A | 2017-01-20 A | 7 | 100% |  | 2017-01-20 | 2017-01-23 | 2d |  |  |  | STC; PM [50%]; DVPR1; CLT | 56h | 56h | 2,200 | 2,200 | 2,200 |
| 9 | 1.3 | **IMPLEMENTATION** |  | 45.5d | 2017-01-20 A | 2017-03-24 |  | 56% | 20.22d | 2017-01-24 | 2017-03-28 | 46d | 1.5d |  |  |  | 480h | 272h | 22,425 | 22,800 | 12,725 |
| 10 | 1.3.1 | Coding - Alpha version |  | 6d | 2017-01-20 A | 2017-01-30 A | 8 | 100% |  | 2017-01-24 | 2017-02-01 | 7d |  |  |  | DVPR2; DVPR1 | 96h | 96h | 4,500 | 5,250 | 4,500 |
| 11 | 1.3.2 | Debugging phase 1 (following internal Alpha testing) |  | 3d | 2017-02-02 A | 2017-02-07 A | 27, 10 | 100% |  | 2017-02-06 | 2017-02-08 | 3d |  |  |  | DVPR2; DVPR1 | 48h | 48h | 2,250 | 2,250 | 2,250 |
| 12 | 1.3.3 | Production of Alpha version and delivery to client |  | 1d | 2017-02-08 A | 2017-02-09 A | 22 | 100% |  | 2017-02-10 | 2017-02-10 | 1d |  |  |  | DVPR2 | 8h | 8h | 350 | 350 | 350 |
| 13 | 1.3.4 | Debugging phase 2 (following client Alpha testing) |  | 1.5d | 2017-02-13 A | 2017-02-14 A | 28 | 100% |  | 2017-02-15 | 2017-02-16 | 2d |  |  |  | DVPR1; DVPR2 | 24h | 24h | 1,125 | 1,500 | 1,125 |
| 14 | 1.3.5 | Coding - Beta version |  | 9d | 2017-02-15 A | 2017-02-27 | 13 | 67% | 3d | 2017-02-17 | 2017-02-28 | 8d | 24.5d | 0d |  | DVPR2; DVPR1 | 144h | 96h | 6,750 | 6,000 | 4,500 |
| 15 | 1.3.6 | Debugging phase 3 (following internal Beta testing) |  | 3d | 2017-02-28 | 2017-03-02 | 29, 14 |  |  | 2017-03-02 | 2017-03-06 | 3d | 1.5d | 0d |  | DVPR2; DVPR1 | 48h |  | 2,250 | 2,250 |  |
| 16 | 1.3.7 | Production of Beta version and delivery to client |  | 1d | 2017-03-07 | 2017-03-07 | 24 |  |  | 2017-03-09 | 2017-03-09 | 1d | 1.5d | 0d |  | DVPR2 | 8h |  | 350 | 350 |  |
| 17 | 1.3.8 | Debugging phase 4 (following client Beta testing) |  | 4d | 2017-03-14 | 2017-03-17 | 30 |  |  | 2017-03-16 | 2017-03-21 | 4d | 1.5d | 0d |  | DVPR1; DVPR2 | 64h |  | 3,000 | 3,000 |  |
| 18 | 1.3.9 | Production of Final version and delivery to client |  | 1d | 2017-03-20 | 2017-03-20 | 17 |  |  | 2017-03-22 | 2017-03-22 | 1d | 1.5d | 0d |  | DVPR2 | 8h |  | 350 | 350 |  |
| 19 | 1.3.10 | Debugging phase 5 & delivery (following client Final testing) |  | 2d | 2017-03-23 | 2017-03-24 | 31 |  |  | 2017-03-27 | 2017-03-28 | 2d | 1.5d | 0d |  | DVPR2; DVPR1 | 32h |  | 1,500 | 1,500 |  |
| 20 | 1.4 | **INTEGRATION** |  | 22.5d | 2017-02-02 A | 2017-03-06 |  | 40% | 13.5d | 2017-02-06 | 2017-03-08 | 23d | 1.5d |  |  |  | 40h | 16h | 1,050 | 1,050 | 350 |
| 21 | 1.4.1 | Delivery of content subset by client |  | 1d | 2017-02-02 A | 2017-02-03 A | 11FF-2d | 100% |  | 2017-02-06 | 2017-02-06 | 1d |  |  |  | CLT | 8h | 8h |  |  |  |
| 22 | 1.4.2 | Integration of content subset |  | 1d | 2017-02-07 A | 2017-02-08 A | 21, 11 | 100% |  | 2017-02-09 | 2017-02-09 | 1d |  |  |  | DVPR2 | 8h | 8h | 350 | 350 | 350 |
| 23 | 1.4.3 | Delivery of complementary content by client |  | 1d | 2017-02-28 | 2017-02-28 | 15FF-2d |  |  | 2017-03-02 | 2017-03-02 | 1d | 3.5d | 2d |  | CLT | 8h |  |  |  |  |
| 24 | 1.4.4 | Integration of complementary content |  | 2d | 2017-03-03 | 2017-03-06 | 23, 15 |  |  | 2017-03-07 | 2017-03-08 | 2d | 1.5d | 0d |  | DVPR2 | 16h |  | 700 | 700 |  |

| ID | WBS | Task | Duration | Start | Finish | Predecessors | Complete | Remaining | Baseline start | Baseline finish | Baseline duration | Total slack | Free slack | Constraint | Resources | Work | Actual work | Cost | Baseline cost | Actual cost |
| --- | --- | --- | --- | --- | --- | --- | --- | --- | --- | --- | --- | --- | --- | --- | --- | --- | --- | --- | --- | --- |
| 25 | 1.5 | **TESTING & ACCEPTANCE** | 46.5d | 2017-01-20 A | 2017-03-27 |  | 52% | 22.14d | 2017-01-24 | 2017-03-29 | 47d | 1.5d |  |  |  | 244h | 140h | 7,075 | 7,675 | 5,275 |
| 26 | 1.5.1 | Prepare test plan and test cases | 5d | 2017-01-20 A | 2017-01-27 A | 8 | 100% |  | 2017-01-24 | 2017-01-30 | 5d |  |  |  | STC [50%]; JTC | 60h | 60h | 2,875 | 2,875 | 2,875 |
| 27 | 1.5.2 | Internal testing - Alpha version | 3d | 2017-01-27 A | 2017-02-01 A | 10SS+3d, 26 | 100% |  | 2017-01-31 | 2017-02-03 | 4d |  |  |  | TSTR1; TSTR2 | 48h | 48h | 1,800 | 2,400 | 1,800 |
| 28 | 1.5.3 | Alpha testing by client | 2d | 2017-02-09 A | 2017-02-13 A | 12 | 100% |  | 2017-02-13 | 2017-02-14 | 2d |  |  |  | CLT | 16h | 16h |  |  |  |
| 29 | 1.5.4 | Internal testing - Beta version | 4d | 2017-02-22 A | 2017-02-27 | 14SS+5d | 25% | 3d | 2017-02-24 | 2017-03-01 | 4d | 1.5d | 0d |  | TSTR1; TSTR2 | 64h | 16h | 2,400 | 2,400 | 600 |
| 30 | 1.5.5 | Beta testing by client | 4d | 2017-03-08 | 2017-03-13 | 16 |  |  | 2017-03-10 | 2017-03-15 | 4d | 1.5d | 0d |  | CLT | 32h |  |  |  |  |
| 31 | 1.5.6 | Final testing by client | 2d | 2017-03-21 | 2017-03-22 | 18 |  |  | 2017-03-23 | 2017-03-24 | 2d | 1.5d | 0d |  | CLT | 16h |  |  |  |  |
| 32 | 1.5.7 | Acceptance by client | 1d | 2017-03-27 | 2017-03-27 | 19 |  |  | 2017-03-29 | 2017-03-29 | 1d | 1.5d | 0d |  | CLT | 8h |  |  |  |  |
| 33 | 1.6 | DEPLOYMENT AT CLIENT'S SITE | 2d | 2017-03-28 | 2017-03-29 | 32 |  |  | 2017-03-30 | 2017-03-31 | 2d | 1.5d |  |  | DVPR2; JTC; TRAVEL [0.1%] | 32h |  | 2,150 | 2,150 |  |
| 34 | 1.7 | PROJECT MANAGEMENT (After Req'ts WP & before Closure) | 60d | 2017-01-06 A | 2017-03-31 | 2, 33FF | 55% | 27d | 2017-01-09 | 2017-03-31 | 60d | 0d |  | start no earlier than 2012-01-06 | PM [50%] | 240h | 132h | 15,000 | 15,000 | 8,250 |
| 35 | 1.8 | PROJECT CLOSURE | 1d | 2017-03-31 | 2017-04-03 | 34 |  |  | 2017-04-03 | 2017-04-03 | 1d | 0d |  |  | DVPR1; PM; STC; TSTR1; CLT [50%] | 36h |  | 1,650 | 1,650 |  |
